# planificacion

Schedule from MS Project, 2016-03-01 to 2016-06-20, 4 hours a day.

## Calendars

- eps-ingenieria-usac: Mon-Fri 08:00-12:00, 13:00-17:00; Sat-Sun off.

## Resources

| Resource |
| --- |
| JG |
| CR |
| SB |

## Schedule

| ID | WBS | Task | Duration | Start | Finish | Predecessors | Total slack | Free slack | Resources | Work |
| --- | --- | --- | --- | --- | --- | --- | --- | --- | --- | --- |
| 1 | 1 | **ANALISIS Y DISEñO DEL SISTEMA** | 65d | 2016-03-01 | 2016-04-14 |  | 0d |  |  | 520h |
| 2 | 1.1 | Analisis de requerimientos del sistema | 160h | 2016-03-01 | 2016-03-28 |  | 0d |  | JG; CR | 320h |
| 3 | 1.2 | Diseño del sistema | 80h | 2016-03-29 | 2016-04-11 | 2 | 0d |  | JG; CR | 160h |
| 4 | 1.3 | Diseño y creación de la página web basándose en los estándares de COED | 20h | 2016-04-12 | 2016-04-14 | 3 | 0d |  | JG; CR | 40h |
| 5 | 2 | **ARQUITECTURA BASE DEL SISTEMA** | 13d | 2016-04-14 | 2016-04-22 |  | 0d |  |  | 88h |
| 6 | 2.1 | **Gestión de Roles del sistema:** | 4.5d | 2016-04-14 | 2016-04-18 | 4 | 85.5d |  |  | 18h |
| 7 | 2.1.1 | Agregar nuevos roles | 6h | 2016-04-14 | 2016-04-15 | 4 | 85.5d | 0d | CR | 6h |
| 8 | 2.1.2 | Asignar privilegios a un rol existente | 6h | 2016-04-15 | 2016-04-15 | 7 | 86.5d | 0d | CR | 6h |
| 9 | 2.1.3 | Revocar privilegios a un rol existente | 6h | 2016-04-18 | 2016-04-18 | 8 | 85.5d | 0d | CR | 6h |
| 10 | 2.2 | **Gestión de Usuarios:** | 13d | 2016-04-14 | 2016-04-22 |  | 0d |  |  | 70h |
| 11 | 2.2.1 | Agregar nuevos usuarios | 6h | 2016-04-14 | 2016-04-15 | 4 | 0d |  | JG | 6h |
| 12 | 2.2.2 | Eliminar usuarios existentes | 6h | 2016-04-15 | 2016-04-15 | 11 | 0d |  | JG | 6h |
| 13 | 2.2.3 | Actualizar información de un usuario existente | 6h | 2016-04-18 | 2016-04-18 | 12 | 0d |  | JG | 6h |
| 14 | 2.2.4 | Asignar rol a un usuario existente | 6h | 2016-04-18 | 2016-04-19 | 13 | 0d |  | JG | 6h |
| 15 | 2.2.5 | Revocar rol a un usuario existente | 6h | 2016-04-19 | 2016-04-20 | 14 | 0d |  | JG | 6h |
| 16 | 2.2.6 | Darse de alta (registro) en la página inicial del sitio web | 8h | 2016-04-20 | 2016-04-21 | 15 | 0d |  | CR | 8h |
| 17 | 2.2.7 | **Control de accesos** | 8.5d | 2016-04-18 | 2016-04-22 |  | 81.5d |  |  | 32h |
| 18 | 2.2.7.1 | Autenticar un usuario | 6h | 2016-04-18 | 2016-04-19 | 9 | 85.5d | 0d | CR | 6h |
| 19 | 2.2.7.2 | Cambio de contraseña | 6h | 2016-04-19 | 2016-04-20 | 18 | 85.5d | 0d | CR | 6h |
| 20 | 2.2.7.3 | Recuperar contraseña | 6h | 2016-04-20 | 2016-04-20 | 19 | 86.5d |  | CR | 6h |
| 21 | 2.2.7.4 | Gestión de la política de contraseñas | 14h | 2016-04-21 | 2016-04-22 | 16 | 81.5d |  | JG | 14h |
| 22 | 3 | **SIMULADOR VIRTUAL DE EXAMENES** | 85d | 2016-04-21 | 2016-06-20 |  | 0d |  |  | 340h |
| 23 | 3.1 | **Categorización del contenido de Tutorías y Mentorías** | 4.5d | 2016-04-21 | 2016-04-25 |  | 0d |  |  | 18h |
| 24 | 3.1.1 | Agregar nuevas categorías | 6h | 2016-04-21 | 2016-04-21 | 16 | 0d |  | JG | 6h |
| 25 | 3.1.2 | Eliminar categorías | 6h | 2016-04-22 | 2016-04-22 | 24 | 0d |  | JG | 6h |
| 26 | 3.1.3 | Actualizar categorías | 6h | 2016-04-22 | 2016-04-25 | 25 | 0d |  | JG | 6h |

| ID | WBS | Task | Duration | Start | Finish | Predecessors | Total slack | Resources | Work |
| --- | --- | --- | --- | --- | --- | --- | --- | --- | --- |
| 27 | 3.2 | **Diseñador de preguntas y ejercicios** | 56.5d | 2016-04-25 | 2016-06-02 |  | 0d |  | 226h |
| 28 | 3.2.1 | **Secciones** | 4.5d | 2016-04-25 | 2016-04-27 |  | 0d |  | 18h |
| 29 | 3.2.1.1 | Agregar nuevas secciones | 6h | 2016-04-25 | 2016-04-26 | 26 | 0d | JG | 6h |
| 30 | 3.2.1.2 | Eliminar secciones | 6h | 2016-04-26 | 2016-04-26 | 29 | 0d | JG | 6h |
| 31 | 3.2.1.3 | Actualizar secciones | 6h | 2016-04-27 | 2016-04-27 | 30 | 0d | JG | 6h |
| 32 | 3.2.2 | **Preguntas y ejercicios** | 26d | 2016-04-27 | 2016-05-16 |  | 0d |  | 104h |
| 33 | 3.2.2.1 | Agregar nuevas preguntas y ejercicios | 12h | 2016-04-27 | 2016-04-29 | 31 | 0d | JG | 12h |
| 34 | 3.2.2.2 | Eliminar preguntas y ejercicios | 4h | 2016-04-29 | 2016-04-29 | 33 | 0d | JG | 4h |
| 35 | 3.2.2.3 | Actualizar preguntas y ejercicios | 12h | 2016-04-29 | 2016-05-03 | 34 | 0d | JG | 12h |
| 36 | 3.2.2.4 | Capacidad de reordenar las preguntas y ejercicios configurados | 12h | 2016-05-03 | 2016-05-04 | 35 | 0d | JG | 12h |
| 37 | 3.2.2.5 | **Tipos de preguntas y ejercicios** | 10d | 2016-05-04 | 2016-05-11 |  | 0d |  | 40h |
| 38 | 3.2.2.5.1 | Respuesta abierta | 8h | 2016-05-04 | 2016-05-05 | 36 | 0d | JG | 8h |
| 39 | 3.2.2.5.2 | Selección múltiple, respuesta única | 8h | 2016-05-05 | 2016-05-06 | 38 | 0d | JG | 8h |
| 40 | 3.2.2.5.3 | Selección múltiple, varias respuestas | 8h | 2016-05-06 | 2016-05-09 | 39 | 0d | JG | 8h |
| 41 | 3.2.2.5.4 | Permitir la opción de “otros” en respuesta de selección múltiple | 8h | 2016-05-09 | 2016-05-10 | 40 | 0d | JG | 8h |
| 42 | 3.2.2.5.5 | Preguntas y ejercicios con respuesta obligatoria u opcional | 8h | 2016-05-10 | 2016-05-11 | 41 | 0d | JG | 8h |
| 43 | 3.2.2.6 | Capacidad de cambiar tipo de pregunta y ejercicio | 8h | 2016-05-11 | 2016-05-12 | 42 | 0d | JG | 8h |
| 44 | 3.2.2.7 | Capacidad de uso de catálogos existente en la base de datos | 8h | 2016-05-12 | 2016-05-13 | 43 | 0d | JG | 8h |
| 45 | 3.2.2.8 | Capacidad de asignar ponderación a preguntas y ejercicios | 8h | 2016-05-13 | 2016-05-16 | 44 | 0d | JG | 8h |
| 46 | 3.2.3 | Vista preliminar de preguntas y ejercicios configurados | 26h | 2016-05-16 | 2016-05-19 | 45 | 0d | JG | 26h |
| 47 | 3.2.4 | Capacidad de almacenar respuestas en una tabla/campo de la base de datos | 20h | 2016-05-20 | 2016-05-24 | 46 | 0d | JG | 20h |
| 48 | 3.2.5 | Generación de código de base de datos para su instalación en la base de datos | 8h | 2016-05-24 | 2016-05-25 | 47 | 0d | JG | 8h |
| 49 | 3.2.6 | Capacidad de vincular el contenido del ejercicio a datos existentes dentro de la base de datos | 12h | 2016-05-25 | 2016-05-26 | 48 | 0d | JG | 12h |
| 50 | 3.2.7 | Generar cantidad aleatoria de número de preguntas o ejercicios del total de ejercicios existentes | 6h | 2016-05-27 | 2016-05-27 | 49 | 0d | JG | 6h |
| 51 | 3.2.8 | Evaluar respuestas y mostrar nota obtenida | 12h | 2016-05-27 | 2016-05-31 | 50 | 0d | JG | 12h |
| 52 | 3.2.9 | Capacidad de generar un archivo en formato PDF en ejercicios configurados | 20h | 2016-05-31 | 2016-06-02 | 51 | 0d | JG | 20h |
| 53 | 3.3 | Creación de Manual de usuario | 30h | 2016-06-02 | 2016-06-08 | 52 | 0d | JG | 30h |
| 54 | 3.4 | Creación de Manual técnico | 14h | 2016-06-08 | 2016-06-10 | 53 | 0d | JG | 14h |
| 55 | 3.5 | Capacitación de usuarios. | 8h | 2016-06-10 | 2016-06-13 | 54 | 0d | JG | 8h |

| ID | WBS | Task | Duration | Start | Finish | Predecessors | Total slack | Resources | Work |
| --- | --- | --- | --- | --- | --- | --- | --- | --- | --- |
| 56 | 3.6 | **Gestor de material de apoyo** | 6d | 2016-06-13 | 2016-06-16 |  | 0d |  | 24h |
| 57 | 3.6.1 | Usuarios administradores pueden cargar, borrar y reorganizar mediante directorios el contenido | 12h | 2016-06-13 | 2016-06-14 | 55 | 0d | JG | 12h |
| 58 | 3.6.2 | Usuarios de consulta pueden visualizar el contenido únicamente | 12h | 2016-06-14 | 2016-06-16 | 57 | 0d | JG | 12h |
| 59 | 3.7 | Gestión de copias de respaldo de la base de datos | 20h | 2016-06-16 | 2016-06-20 | 58 | 0d | JG | 20h |
| 60 | 4 | **INTELIGENCIA DE NEGOCIO AUTOGESTIONABLE** | 85d | 2016-04-21 | 2016-06-20 |  | 0d |  | 340h |
| 61 | 4.1 | **Categorización de reportes** | 4.5d | 2016-04-21 | 2016-04-25 |  | 0d |  | 18h |
| 62 | 4.1.1 | Agregar nuevas categorías | 6h | 2016-04-21 | 2016-04-21 | 16 | 0d | CR | 6h |
| 63 | 4.1.2 | Eliminar categorías | 6h | 2016-04-22 | 2016-04-22 | 62 | 0d | CR | 6h |
| 64 | 4.1.3 | Actualizar categorías | 6h | 2016-04-22 | 2016-04-25 | 63 | 0d | CR | 6h |
| 65 | 4.2 | **Diseñador de reportes** | 68d | 2016-04-25 | 2016-06-10 |  | 0d |  | 272h |
| 66 | 4.2.1 | **Configuración de conexiones a base de datos** | 4.5d | 2016-04-25 | 2016-04-27 |  | 0d |  | 18h |
| 67 | 4.2.1.1 | Agregar nuevas conexiones | 6h | 2016-04-25 | 2016-04-26 | 64 | 0d | CR | 6h |
| 68 | 4.2.1.2 | Eliminar conexiones | 6h | 2016-04-26 | 2016-04-26 | 67 | 0d | CR | 6h |
| 69 | 4.2.1.3 | Actualizar conexiones | 6h | 2016-04-27 | 2016-04-27 | 68 | 0d | CR | 6h |
| 70 | 4.2.2 | **Reportes** | 47d | 2016-04-27 | 2016-05-31 |  | 0d |  | 188h |
| 71 | 4.2.2.1 | Agregar nuevos reportes | 12h | 2016-04-27 | 2016-04-29 | 69 | 0d | CR | 12h |
| 72 | 4.2.2.2 | Eliminar reportes | 6h | 2016-04-29 | 2016-04-29 | 71 | 0d | CR | 6h |
| 73 | 4.2.2.3 | Actualizar reportes | 6h | 2016-05-02 | 2016-05-02 | 72 | 0d | CR | 6h |
| 74 | 4.2.2.4 | Capacidad de reordenar los reportes configurados | 12h | 2016-05-02 | 2016-05-04 | 73 | 0d | CR | 12h |
| 75 | 4.2.2.5 | Categorización de reportes | 12h | 2016-05-04 | 2016-05-05 | 74 | 0d | CR | 12h |
| 76 | 4.2.2.6 | Habilitación y des habilitación de reportes | 4h | 2016-05-05 | 2016-05-06 | 75 | 0d | CR | 4h |
| 77 | 4.2.2.7 | Validar consulta SQL mostrando las primeras 10 filas de la consulta | 12h | 2016-05-06 | 2016-05-09 | 76 | 0d | CR | 12h |
| 78 | 4.2.2.8 | Capacidad de configurar parámetros en la consulta SQL de forma dinámica | 12h | 2016-05-09 | 2016-05-11 | 77 | 0d | CR | 12h |
| 79 | 4.2.2.9 | Personalizar encabezado de la columna a mostrar | 6h | 2016-05-11 | 2016-05-11 | 78 | 0d | CR | 6h |
| 80 | 4.2.2.10 | Capacidad de configurar filtros para ser utilizados en el reporte a generar | 20h | 2016-05-12 | 2016-05-16 | 79 | 0d | CR | 20h |
| 81 | 4.2.2.11 | Personalización de la columna a mostrar, por ejemplo: negrita, signo de Quetzal, etc. | 12h | 2016-05-16 | 2016-05-17 | 80 | 0d | CR | 12h |

| ID | WBS | Task | Duration | Start | Finish | Predecessors | Total slack | Resources | Work |
| --- | --- | --- | --- | --- | --- | --- | --- | --- | --- |
| 82 | 4.2.2.12 | **Funciones de agrupación** | 3d | 2016-05-18 | 2016-05-19 |  | 0d |  | 12h |
| 83 | 4.2.2.12.1 | Suma | 4h | 2016-05-18 | 2016-05-18 | 81 | 0d | CR | 4h |
| 84 | 4.2.2.12.2 | Conteo | 4h | 2016-05-18 | 2016-05-18 | 83 | 0d | CR | 4h |
| 85 | 4.2.2.12.3 | Promedio | 4h | 2016-05-19 | 2016-05-19 | 84 | 0d | CR | 4h |
| 86 | 4.2.2.13 | **Personalización de parámetros del reporte** | 12.5d | 2016-05-19 | 2016-05-27 |  | 0d |  | 50h |
| 87 | 4.2.2.13.1 | Ordenamiento de parámetros | 6h | 2016-05-19 | 2016-05-20 | 85 | 0d | CR | 6h |
| 88 | 4.2.2.13.2 | Campo asociado al parámetro | 6h | 2016-05-20 | 2016-05-20 | 87 | 0d | CR | 6h |
| 89 | 4.2.2.13.3 | Etiqueta a mostrar del parámetro | 6h | 2016-05-23 | 2016-05-23 | 88 | 0d | CR | 6h |
| 90 | 4.2.2.13.4 | **Capacidad de definir el tipo de control a mostrar** | 8d | 2016-05-23 | 2016-05-27 |  | 0d |  | 32h |
| 91 | 4.2.2.13.4.1 | Texto libre | 6h | 2016-05-23 | 2016-05-24 | 89 | 0d | CR | 6h |
| 92 | 4.2.2.13.4.2 | Calendario | 6h | 2016-05-24 | 2016-05-25 | 91 | 0d | CR | 6h |
| 93 | 4.2.2.13.4.3 | Lista de valores | 8h | 2016-05-25 | 2016-05-26 | 92 | 0d | CR | 8h |
| 94 | 4.2.2.13.4.4 | Consulta SQL | 12h | 2016-05-26 | 2016-05-27 | 93 | 0d | CR | 12h |
| 95 | 4.2.2.14 | Capacidad de seleccionar un valor predeterminado | 6h | 2016-05-27 | 2016-05-30 | 94 | 0d | CR | 6h |
| 96 | 4.2.2.15 | Parámetro obligatorio u opcional | 6h | 2016-05-30 | 2016-05-31 | 95 | 0d | CR | 6h |
| 97 | 4.2.3 | Tipificación de parámetros ingresados por el usuario o por el sistema | 12h | 2016-05-31 | 2016-06-01 | 96 | 0d | CR | 12h |
| 98 | 4.2.4 | Asignación de permisos por reporte a nivel de usuario | 20h | 2016-06-01 | 2016-06-06 | 97 | 0d | CR | 20h |
| 99 | 4.2.5 | Capacidad de exportar el reporte en formato Excel | 26h | 2016-06-06 | 2016-06-09 | 98 | 0d | CR | 26h |
| 100 | 4.2.6 | Capacidad de integrar un reporte a otros sistemas mediante código embebido | 8h | 2016-06-09 | 2016-06-10 | 99 | 0d | CR | 8h |
| 101 | 4.3 | Creación de Manual de usuario modulo de reportes | 30h | 2016-06-10 | 2016-06-16 | 100 | 0d | CR | 30h |
| 102 | 4.4 | Creación de Manual técnico modulo de reportes | 12h | 2016-06-16 | 2016-06-17 | 101 | 0d | CR | 12h |
| 103 | 4.5 | Capacitación de usuarios | 8h | 2016-06-17 | 2016-06-20 | 102 | 0d | CR | 8h |
